# 50CMSIT - IT Dev Template 2012-04-16 Project 2010 Format

Schedule from MS Project, 2011-09-08 to 2011-10-19.
CMS

## Calendars

- CMS Federal Holidays: Mon-Fri 08:00-12:00, 13:00-17:00; Sat-Sun off. Exceptions (off unless hours are given): 2011-10-10 (Columbus Day).

## Schedule

| ID | WBS | Task | Type | Duration | Start | Finish | Predecessors | Baseline start | Baseline finish | Baseline duration | Total slack | Free slack | Constraint |
| --- | --- | --- | --- | --- | --- | --- | --- | --- | --- | --- | --- | --- | --- |
| 1 | 1 | ****TEMPLATE** IT Development Project: < PROJECT NAME >** |  | 29d | 2011-09-08 | 2011-10-19 |  | 2011-07-27 | 2011-09-12 | 34d | 0d |  |  |
| 2 | 1.1 | Project Start |  | 1d | 2011-09-08 | 2011-09-08 |  | 2011-07-27 | 2011-07-27 | 1d | 0d |  | start no earlier than 2011-09-08 |
| 3 | 1.2 | **Program Management Activity Phase (PROJECT NAME)** |  | 1d | 2011-09-09 | 2011-09-09 |  | 2011-07-28 | 2011-07-28 | 1d | 24d | 0d |  |
| 4 | 1.2.1 | Task Program Management Activity |  | 1d | 2011-09-09 | 2011-09-09 | 2 | 2011-07-28 | 2011-07-28 | 1d | 24d |  |  |
| 5 | 1.3 | MILESTONE: Program Management Activity Phase Complete (PROJECT NAME) | milestone | 0d | 2011-09-09 | 2011-09-09 | 3 | 2011-07-28 | 2011-07-28 | 0d | 27d |  |  |
| 6 | 1.4 | **Acquisition Activity Phase - Federal Staff Only (PROJECT NAME)** |  | 4d | 2011-09-09 | 2011-09-14 |  | 2011-07-28 | 2011-08-02 | 4d | 19d | 0d |  |
| 7 | 1.4.1 | Identify Bidders |  | 1d | 2011-09-09 | 2011-09-09 | 2 | 2011-07-28 | 2011-07-28 | 1d | 19d | 0d |  |
| 8 | 1.4.2 | Issue RFP |  | 1d | 2011-09-12 | 2011-09-12 | 7 | 2011-07-29 | 2011-07-29 | 1d | 19d | 0d |  |
| 9 | 1.4.3 | Evaluate Proposals |  | 1d | 2011-09-13 | 2011-09-13 | 8 | 2011-08-01 | 2011-08-01 | 1d | 19d | 0d |  |
| 10 | 1.4.4 | Award Contract |  | 1d | 2011-09-14 | 2011-09-14 | 9 | 2011-08-02 | 2011-08-02 | 1d | 19d |  |  |
| 11 | 1.5 | MILESTONE: Acquisition Activity Phase Complete (PROJECT NAME) | milestone | 0d | 2011-09-14 | 2011-09-14 | 6 | 2011-08-02 | 2011-08-02 | 0d | 24d |  |  |
| 12 | 1.6 | **Initiation Phase (PROJECT NAME)** |  | 3d | 2011-09-09 | 2011-09-13 |  | 2011-07-28 | 2011-08-01 | 3d | 0d |  |  |
| 13 | 1.6.1 | **Initiation Phase Tasks** |  | 1d | 2011-09-09 | 2011-09-09 | 2 | 2011-07-28 | 2011-07-28 | 1d | 1d |  |  |
| 14 | 1.6.1.1 | Initiation Phase Task 1 |  | 1d | 2011-09-09 | 2011-09-09 |  | 2011-07-28 | 2011-07-28 | 1d | 1d |  |  |
| 15 | 1.6.1.2 | Initiation Phase Task n |  | 1d | 2011-09-09 | 2011-09-09 |  | 2011-07-28 | 2011-07-28 | 1d | 1d |  |  |
| 16 | 1.6.2 | **Initiation Phase Artifacts** |  | 2d | 2011-09-09 | 2011-09-12 |  | 2011-07-28 | 2011-07-29 | 2d | 0d |  |  |
| 17 | 1.6.2.1 | FINAL: IT Intake Request Form - Federal Staff Only |  | 1d | 2011-09-09 | 2011-09-09 | 2 | 2011-07-28 | 2011-07-28 | 1d | 0d |  |  |
| 18 | 1.6.2.2 | PRELIMINARY: Enterprise Architecture Analysis Artifacts |  | 1d | 2011-09-12 | 2011-09-12 | 17 | 2011-07-29 | 2011-07-29 | 1d | 0d |  |  |
| 19 | 1.6.3 | Schedule and Prepare for Architecture Review (AR) |  | 1d | 2011-09-13 | 2011-09-13 | 16, 13 | 2011-08-01 | 2011-08-01 | 1d | 0d |  |  |
| 20 | 1.6.4 | MILESTONE: Architecture Review (AR) | milestone | 0d | 2011-09-13 | 2011-09-13 | 19 | 2011-08-01 | 2011-08-01 | 0d | 25d |  |  |
| 21 | 1.7 | MILESTONE: Initiation Phase Complete (PROJECT NAME) | milestone | 0d | 2011-09-13 | 2011-09-13 | 12 | 2011-08-01 | 2011-08-01 | 0d | 25d |  |  |
| 22 | 1.8 | **Concept Phase (PROJECT NAME)** |  | 6d | 2011-09-13 | 2011-09-20 |  | 2011-08-01 | 2011-08-16 | 12d | 1d | 0d |  |
| 23 | 1.8.1 | **Concept Phase Tasks** |  | 1d | 2011-09-14 | 2011-09-14 | 19 | 2011-08-02 | 2011-08-02 | 1d | 3d |  |  |
| 24 | 1.8.1.1 | Concept Phase Task 1 |  | 1d | 2011-09-14 | 2011-09-14 |  | 2011-08-02 | 2011-08-02 | 1d | 3d |  |  |
| 25 | 1.8.1.2 | Concept Phase Task n |  | 1d | 2011-09-14 | 2011-09-14 |  | 2011-08-02 | 2011-08-02 | 1d | 3d |  |  |

| ID | WBS | Task | Type | Duration | Start | Finish | Predecessors | Baseline start | Baseline finish | Baseline duration | Total slack | Free slack |
| --- | --- | --- | --- | --- | --- | --- | --- | --- | --- | --- | --- | --- |
| 26 | 1.8.2 | **Concept Phase Artifacts** |  | 5d | 2011-09-13 | 2011-09-19 |  | 2011-08-01 | 2011-08-12 | 10d | 0d |  |
| 27 | 1.8.2.1 | FINAL: High Level Technical Design |  | 1d | 2011-09-14 | 2011-09-14 | 19 | 2011-08-02 | 2011-08-02 | 1d | 0d |  |
| 28 | 1.8.2.2 | FINAL: Project Process Agreement |  | 1d | 2011-09-15 | 2011-09-15 | 27 | 2011-08-03 | 2011-08-03 | 1d | 0d |  |
| 29 | 1.8.2.3 | FINAL: Business Case |  | 1d | 2011-09-16 | 2011-09-16 | 28 | 2011-08-04 | 2011-08-04 | 1d | 0d |  |
| 30 | 1.8.2.4 | FINAL: Project Charter |  | 1d | 2011-09-19 | 2011-09-19 | 29 | 2011-08-05 | 2011-08-05 | 1d | 0d |  |
| 31 | 1.8.2.5 | INTERIM: Enterprise Architecture Analysis Artifacts |  | 1d | 2011-09-13 | 2011-09-13 | 18 | 2011-08-01 | 2011-08-01 | 1d | 4d | 0d |
| 32 | 1.8.2.6 | PRELIMINARY: Requirements Document |  | 1d | 2011-09-14 | 2011-09-14 | 19 | 2011-08-08 | 2011-08-08 | 1d | 3d | 0d |
| 33 | 1.8.2.7 | PRELIMINARY: Section 508 Product Assessment Package |  | 1d | 2011-09-14 | 2011-09-14 | 19 | 2011-08-09 | 2011-08-09 | 1d | 3d | 0d |
| 34 | 1.8.2.8 | PRELIMINARY: Information Security Risk Assessment (ISRA) |  | 1d | 2011-09-14 | 2011-09-14 | 19 | 2011-08-10 | 2011-08-10 | 1d | 3d | 0d |
| 35 | 1.8.2.9 | PRELIMINARY: System Security Plan (SSP) |  | 1d | 2011-09-14 | 2011-09-14 | 19 | 2011-08-11 | 2011-08-11 | 1d | 3d | 0d |
| 36 | 1.8.2.10 | PRELIMINARY: Privacy Impact Assessment (PIA) |  | 1d | 2011-09-14 | 2011-09-14 | 19 | 2011-08-12 | 2011-08-12 | 1d | 3d | 0d |
| 37 | 1.8.2.11 | PRELIMINARY: Contingency Plan |  | 1d | 2011-09-14 | 2011-09-14 | 19 | 2011-08-18 | 2011-08-18 | 1d | 3d | 0d |
| 38 | 1.8.3 | Schedule and Prepare for Investment Selection Review (ISR) |  | 1d | 2011-09-20 | 2011-09-20 | 23, 26 | 2011-08-15 | 2011-08-15 | 1d | 0d |  |
| 39 | 1.8.4 | MILESTONE: Investment Selection Review (ISR) | milestone | 0d | 2011-09-20 | 2011-09-20 | 38 | 2011-08-15 | 2011-08-15 | 0d | 4d | 2d |
| 40 | 1.9 | MILESTONE: Concept Phase Complete (PROJECT NAME) | milestone | 0d | 2011-09-20 | 2011-09-20 | 22 | 2011-08-16 | 2011-08-16 | 0d | 4d | 2d |
| 41 | 1.10 | **Planning Phase (PROJECT NAME)** |  | 7d | 2011-09-14 | 2011-09-22 |  | 2011-08-02 | 2011-08-17 | 12d | 2d | 0d |
| 42 | 1.10.1 | **Planning Phase Tasks** |  | 1d | 2011-09-21 | 2011-09-21 |  | 2011-08-16 | 2011-08-16 | 1d | 0d |  |
| 43 | 1.10.1.1 | Planning Phase Task 1 |  | 1d | 2011-09-21 | 2011-09-21 | 38 | 2011-08-16 | 2011-08-16 | 1d | 0d |  |
| 44 | 1.10.1.2 | Planning Phase Task n |  | 1d | 2011-09-21 | 2011-09-21 | 43SS | 2011-08-16 | 2011-08-16 | 1d | 0d |  |
| 45 | 1.10.2 | **Planning Phase Artifacts** |  | 6d | 2011-09-14 | 2011-09-21 |  | 2011-08-02 | 2011-08-16 | 11d | 0d |  |
| 46 | 1.10.2.1 | FINAL: Enterprise Architecture Analysis Artifacts |  | 1d | 2011-09-14 | 2011-09-14 | 31 | 2011-08-02 | 2011-08-02 | 1d | 5d |  |
| 47 | 1.10.2.2 | **FINAL: Project Management Plan** |  | 1d | 2011-09-21 | 2011-09-21 |  | 2011-08-16 | 2011-08-16 | 1d | 0d |  |
| 48 | 1.10.2.2.1 | SUB-ARTIFACT: Risk Management Plan |  | 1d | 2011-09-21 | 2011-09-21 | 38 | 2011-08-16 | 2011-08-16 | 1d | 0d |  |
| 49 | 1.10.2.2.2 | SUB-ARTIFACT: Acquisition Strategy |  | 1d | 2011-09-21 | 2011-09-21 | 48SS | 2011-08-16 | 2011-08-16 | 1d | 0d |  |
| 50 | 1.10.2.2.3 | SUB-ARTIFACT: Change Management Plan |  | 1d | 2011-09-21 | 2011-09-21 | 48SS | 2011-08-16 | 2011-08-16 | 1d | 0d |  |
| 51 | 1.10.2.2.4 | SUB-ARTIFACT: Configuration Management Plan |  | 1d | 2011-09-21 | 2011-09-21 | 48SS | 2011-08-16 | 2011-08-16 | 1d | 0d |  |
| 52 | 1.10.2.2.5 | SUB-ARTIFACT: Requirements Management Plan |  | 1d | 2011-09-21 | 2011-09-21 | 48SS | 2011-08-16 | 2011-08-16 | 1d | 0d |  |
| 53 | 1.10.2.2.6 | SUB-ARTIFACT: Communications Management Plan |  | 1d | 2011-09-21 | 2011-09-21 | 48SS | 2011-08-16 | 2011-08-16 | 1d | 0d |  |
| 54 | 1.10.2.2.7 | SUB-ARTIFACT: Schedule Management Plan |  | 1d | 2011-09-21 | 2011-09-21 | 48SS | 2011-08-16 | 2011-08-16 | 1d | 0d |  |
| 55 | 1.10.2.2.8 | SUB-ARTIFACT: Work Breakdown Structure (WBS) |  | 1d | 2011-09-21 | 2011-09-21 | 48SS | 2011-08-16 | 2011-08-16 | 1d | 0d |  |
| 56 | 1.10.2.2.9 | SUB-ARTIFACT: Software Process Improvement Plan (SPIP) |  | 1d | 2011-09-21 | 2011-09-21 | 48SS | 2011-08-16 | 2011-08-16 | 1d | 0d |  |
| 57 | 1.10.2.2.10 | SUB-ARTIFACT: IV & V Plan |  | 1d | 2011-09-21 | 2011-09-21 | 48SS | 2011-08-16 | 2011-08-16 | 1d | 0d |  |
| 58 | 1.10.2.2.11 | SUB-ARTIFACT: Quality Management Plan |  | 1d | 2011-09-21 | 2011-09-21 | 48SS | 2011-08-16 | 2011-08-16 | 1d | 0d |  |
| 59 | 1.10.2.2.12 | SUB-ARTIFACT: Financial Management Plan |  | 1d | 2011-09-21 | 2011-09-21 | 48SS | 2011-08-16 | 2011-08-16 | 1d | 0d |  |
| 60 | 1.10.2.2.13 | SUB-ARTIFACT: Subcontractor Management Plan |  | 1d | 2011-09-21 | 2011-09-21 | 48SS | 2011-08-16 | 2011-08-16 | 1d | 0d |  |
| 61 | 1.10.2.2.14 | SUB-ARTIFACT: Performance Measurement Plan |  | 1d | 2011-09-21 | 2011-09-21 | 48SS | 2011-08-16 | 2011-08-16 | 1d | 0d |  |
| 62 | 1.10.2.2.15 | SUB-ARTIFACT: Records Management Plan |  | 1d | 2011-09-21 | 2011-09-21 | 48SS | 2011-08-16 | 2011-08-16 | 1d | 0d |  |
| 63 | 1.10.2.2.16 | SUB-ARTIFACT: Staffing Management Plan |  | 1d | 2011-09-21 | 2011-09-21 | 48SS | 2011-08-16 | 2011-08-16 | 1d | 0d |  |
| 64 | 1.10.2.2.17 | SUB-ARTIFACT: Development Approach Plan |  | 1d | 2011-09-21 | 2011-09-21 | 48SS | 2011-08-16 | 2011-08-16 | 1d | 0d |  |
| 65 | 1.10.2.2.18 | SUB-ARTIFACT: Security Approach |  | 1d | 2011-09-21 | 2011-09-21 | 48SS | 2011-08-16 | 2011-08-16 | 1d | 0d |  |
| 66 | 1.10.2.3 | BASELINE: Project Schedule |  | 1d | 2011-09-21 | 2011-09-21 | 48SS | 2011-08-16 | 2011-08-16 | 1d | 0d |  |
| 67 | 1.10.2.4 | INTERIM: Requirements Document |  | 1d | 2011-09-15 | 2011-09-15 | 32 | 2011-08-08 | 2011-08-08 | 1d | 4d | 0d |
| 68 | 1.10.2.5 | INTERIM: Section 508 Product Assessment Package |  | 1d | 2011-09-15 | 2011-09-15 | 33 | 2011-08-09 | 2011-08-09 | 1d | 4d | 0d |
| 69 | 1.10.2.6 | INTERIM: Information Security Risk Assessment (ISRA) |  | 1d | 2011-09-15 | 2011-09-15 | 34 | 2011-08-10 | 2011-08-10 | 1d | 4d | 0d |
| 70 | 1.10.2.7 | INTERIM: System Security Plan (SSP) |  | 1d | 2011-09-15 | 2011-09-15 | 35 | 2011-08-11 | 2011-08-11 | 1d | 4d | 0d |
| 71 | 1.10.2.8 | INTERIM: Privacy Impact Assessment (PIA) |  | 1d | 2011-09-15 | 2011-09-15 | 36 | 2011-08-15 | 2011-08-15 | 1d | 4d | 0d |
| 72 | 1.10.2.9 | INTERIM: Contingency Plan |  | 1d | 2011-09-15 | 2011-09-15 | 37 | 2011-08-18 | 2011-08-18 | 1d | 4d | 0d |
| 73 | 1.10.2.10 | PRELIMINARY: Risk Register |  | 1d | 2011-09-21 | 2011-09-21 | 38 | 2011-08-16 | 2011-08-16 | 1d | 0d |  |
| 74 | 1.10.2.11 | PRELIMINARY: Logical Data Model |  | 1d | 2011-09-21 | 2011-09-21 | 38 | 2011-08-16 | 2011-08-16 | 1d | 0d |  |
| 75 | 1.10.2.12 | PRELIMINARY: Release Plan |  | 1d | 2011-09-21 | 2011-09-21 | 38 | 2011-08-16 | 2011-08-16 | 1d | 0d |  |
| 76 | 1.10.2.13 | PRELIMINARY: Issues List |  | 1d | 2011-09-21 | 2011-09-21 | 38 | 2011-08-16 | 2011-08-16 | 1d | 0d |  |
| 77 | 1.10.2.14 | PRELIMINARY: Action Items |  | 1d | 2011-09-21 | 2011-09-21 | 38 | 2011-08-16 | 2011-08-16 | 1d | 0d |  |
| 78 | 1.10.2.15 | PRELIMINARY: Decision Log |  | 1d | 2011-09-21 | 2011-09-21 | 38 | 2011-08-16 | 2011-08-16 | 1d | 0d |  |
| 79 | 1.10.2.16 | PRELIMINARY: Lessons Learned |  | 1d | 2011-09-21 | 2011-09-21 | 38 | 2011-08-16 | 2011-08-16 | 1d | 0d |  |
| 80 | 1.10.3 | Schedule and Prepare for Project Baseline Review (PBR) |  | 1d | 2011-09-22 | 2011-09-22 | 42, 45 | 2011-08-17 | 2011-08-17 | 1d | 0d |  |
| 81 | 1.10.4 | MILESTONE: Project Baseline Review (PBR) | milestone | 0d | 2011-09-22 | 2011-09-22 | 80 | 2011-08-17 | 2011-08-17 | 0d | 2d |  |
| 82 | 1.11 | MILESTONE: Planning Phase Complete (PROJECT NAME) | milestone | 0d | 2011-09-22 | 2011-09-22 | 41 | 2011-08-17 | 2011-08-17 | 0d | 18d |  |

| ID | WBS | Task | Type | Duration | Start | Finish | Predecessors | Baseline start | Baseline finish | Baseline duration | Total slack | Free slack |
| --- | --- | --- | --- | --- | --- | --- | --- | --- | --- | --- | --- | --- |
| 83 | 1.12 | **Requirements Analysis Phase (PROJECT NAME)** |  | 7d | 2011-09-16 | 2011-09-26 |  | 2011-08-09 | 2011-08-19 | 9d | 5d | 0d |
| 84 | 1.12.1 | **Requirements Analysis Phase Tasks** |  | 1d | 2011-09-23 | 2011-09-23 |  | 2011-08-18 | 2011-08-18 | 1d | 0d |  |
| 85 | 1.12.1.1 | Requirements Analysis Phase Task 1 |  | 1d | 2011-09-23 | 2011-09-23 | 80 | 2011-08-18 | 2011-08-18 | 1d | 0d |  |
| 86 | 1.12.1.2 | Requirements Analysis Phase Task n |  | 1d | 2011-09-23 | 2011-09-23 | 85SS | 2011-08-18 | 2011-08-18 | 1d | 0d |  |
| 87 | 1.12.2 | **Requirements Analysis Phase Artifacts** |  | 6d | 2011-09-16 | 2011-09-23 |  | 2011-08-09 | 2011-08-18 | 8d | 0d |  |
| 88 | 1.12.2.1 | FINAL: Logical Data Model (LDM) |  | 1d | 2011-09-22 | 2011-09-22 | 74 | 2011-08-17 | 2011-08-17 | 1d | 1d |  |
| 89 | 1.12.2.2 | BASELINE: Requirements Document |  | 1d | 2011-09-16 | 2011-09-16 | 32, 67 | 2011-08-09 | 2011-08-09 | 1d | 5d |  |
| 90 | 1.12.2.3 | INTERIM: Project Schedule |  | 1d | 2011-09-22 | 2011-09-22 | 66, 38 | 2011-08-16 | 2011-08-16 | 1d | 1d | 0d |
| 91 | 1.12.2.4 | INTERIM: Release Plan |  | 1d | 2011-09-22 | 2011-09-22 | 75, 38 | 2011-08-16 | 2011-08-16 | 1d | 1d |  |
| 92 | 1.12.2.5 | INTERIM: Section 508 Product Assessment Package |  | 1d | 2011-09-16 | 2011-09-16 | 33, 68 | 2011-08-09 | 2011-08-09 | 1d | 5d | 0d |
| 93 | 1.12.2.6 | INTERIM: Information Security Risk Assessment (ISRA) |  | 1d | 2011-09-16 | 2011-09-16 | 34, 69 | 2011-08-10 | 2011-08-10 | 1d | 5d | 0d |
| 94 | 1.12.2.7 | INTERIM: System Security Plan (SSP) |  | 1d | 2011-09-16 | 2011-09-16 | 35, 70 | 2011-08-11 | 2011-08-11 | 1d | 5d | 0d |
| 95 | 1.12.2.8 | INTERIM: Privacy Impact Assessment (PIA) |  | 1d | 2011-09-16 | 2011-09-16 | 36, 71 | 2011-08-15 | 2011-08-15 | 1d | 5d | 0d |
| 96 | 1.12.2.9 | INTERIM: Contingency Plan |  | 1d | 2011-09-16 | 2011-09-16 | 37, 72 | 2011-08-18 | 2011-08-18 | 1d | 5d | 0d |
| 97 | 1.12.2.10 | INTERIM: Risk Register |  | 1d | 2011-09-22 | 2011-09-22 | 38, 73 | 2011-08-16 | 2011-08-16 | 1d | 1d | 0d |
| 98 | 1.12.2.11 | INTERIM: Issues List |  | 1d | 2011-09-22 | 2011-09-22 | 76, 38 | 2011-08-16 | 2011-08-16 | 1d | 1d | 0d |
| 99 | 1.12.2.12 | INTERIM: Action Items |  | 1d | 2011-09-22 | 2011-09-22 | 77, 38 | 2011-08-16 | 2011-08-16 | 1d | 1d | 0d |
| 100 | 1.12.2.13 | INTERIM: Decision Log |  | 1d | 2011-09-22 | 2011-09-22 | 78, 38 | 2011-08-16 | 2011-08-16 | 1d | 1d | 0d |
| 101 | 1.12.2.14 | INTERIM: Lessons Learned |  | 1d | 2011-09-22 | 2011-09-22 | 79, 38 | 2011-08-16 | 2011-08-16 | 1d | 1d | 0d |
| 102 | 1.12.2.15 | PRELIMINARY: Test Plan |  | 1d | 2011-09-23 | 2011-09-23 | 38, 80 | 2011-08-18 | 2011-08-18 | 1d | 0d |  |
| 103 | 1.12.2.16 | PRELIMINARY: System of Records Notice (SORN) |  | 1d | 2011-09-23 | 2011-09-23 | 80, 38 | 2011-08-18 | 2011-08-18 | 1d | 0d |  |
| 104 | 1.12.3 | Schedule and Prepare for Requirements Review (RR) |  | 1d | 2011-09-26 | 2011-09-26 | 84, 87 | 2011-08-19 | 2011-08-19 | 1d | 0d |  |
| 105 | 1.12.4 | MILESTONE: Requirements Review (RR) | milestone | 0d | 2011-09-26 | 2011-09-26 | 104 | 2011-08-19 | 2011-08-19 | 0d | 16d |  |
| 106 | 1.13 | MILESTONE: Requirements Analysis Phase Complete (PROJECT NAME) | milestone | 0d | 2011-09-26 | 2011-09-26 | 83 | 2011-08-19 | 2011-08-19 | 0d | 16d |  |

Notes:
- 102: Also see CMS Testing Framework Overview (http://www.cms.gov/SystemLifecycleFramework/downloads/CMSTestingFrameworkOverview.pdf)

| ID | WBS | Task | Type | Duration | Start | Finish | Predecessors | Baseline start | Baseline finish | Baseline duration | Total slack | Free slack |
| --- | --- | --- | --- | --- | --- | --- | --- | --- | --- | --- | --- | --- |
| 107 | 1.14 | **Design Phase (PROJECT NAME)** |  | 10d | 2011-09-19 | 2011-09-30 |  | 2011-08-19 | 2011-08-25 | 5d | 6d | 0d |
| 108 | 1.14.1 | **Preliminary Design** |  | 8d | 2011-09-19 | 2011-09-28 |  | 2011-08-22 | 2011-08-23 | 2d | 6d | 0d |
| 109 | 1.14.1.1 | **Preliminary Design Phase Tasks** |  | 1d | 2011-09-27 | 2011-09-27 |  | 2011-08-22 | 2011-08-22 | 1d | 0d |  |
| 110 | 1.14.1.1.1 | Preliminary Design Phase Task 1 |  | 1d | 2011-09-27 | 2011-09-27 | 104 | 2011-08-22 | 2011-08-22 | 1d | 0d |  |
| 111 | 1.14.1.1.2 | Preliminary Design Phase Task n |  | 1d | 2011-09-27 | 2011-09-27 | 110SS | 2011-08-22 | 2011-08-22 | 1d | 0d |  |
| 112 | 1.14.1.2 | **Preliminary Design Phase Artifacts** |  | 7d | 2011-09-19 | 2011-09-27 |  | 2011-08-22 | 2011-08-22 | 1d | 0d |  |
| 113 | 1.14.1.2.1 | INTERIM: Project Schedule |  | 1d | 2011-09-23 | 2011-09-23 | 38, 90 | 2011-08-16 | 2011-08-16 | 1d | 2d | 0d |
| 114 | 1.14.1.2.2 | INTERIM: Section 508 Product Assessment Package |  | 1d | 2011-09-19 | 2011-09-19 | 33, 92 | 2011-08-09 | 2011-08-09 | 1d | 6d | 0d |
| 115 | 1.14.1.2.3 | INTERIM: Information Security Risk Assessment (ISRA) |  | 1d | 2011-09-19 | 2011-09-19 | 34, 93 | 2011-08-10 | 2011-08-10 | 1d | 6d | 0d |
| 116 | 1.14.1.2.4 | INTERIM: System Security Plan (SSP) |  | 1d | 2011-09-19 | 2011-09-19 | 35, 94 | 2011-08-11 | 2011-08-11 | 1d | 6d | 0d |
| 117 | 1.14.1.2.5 | INTERIM: Privacy Impact Assessment (PIA) |  | 1d | 2011-09-19 | 2011-09-19 | 36, 95 | 2011-08-15 | 2011-08-15 | 1d | 6d | 0d |
| 118 | 1.14.1.2.6 | INTERIM: Contingency Plan |  | 1d | 2011-09-19 | 2011-09-19 | 37, 96 | 2011-08-18 | 2011-08-18 | 1d | 6d | 0d |
| 119 | 1.14.1.2.7 | INTERIM: Risk Register |  | 1d | 2011-09-23 | 2011-09-23 | 38, 97 | 2011-08-16 | 2011-08-16 | 1d | 2d | 0d |
| 120 | 1.14.1.2.8 | INTERIM: Issues List |  | 1d | 2011-09-23 | 2011-09-23 | 39, 98 | 2011-08-16 | 2011-08-16 | 1d | 2d | 0d |
| 121 | 1.14.1.2.9 | INTERIM: Action Items |  | 1d | 2011-09-23 | 2011-09-23 | 40, 99 | 2011-08-16 | 2011-08-16 | 1d | 2d | 0d |
| 122 | 1.14.1.2.10 | INTERIM: Decision Log |  | 1d | 2011-09-23 | 2011-09-23 | 41, 100 | 2011-08-16 | 2011-08-16 | 1d | 2d | 0d |
| 123 | 1.14.1.2.11 | INTERIM: Lessons Learned |  | 1d | 2011-09-23 | 2011-09-23 | 42, 101 | 2011-08-16 | 2011-08-16 | 1d | 2d | 0d |
| 124 | 1.14.1.2.12 | INTERIM: Test Plan |  | 1d | 2011-09-26 | 2011-09-26 | 38, 102 | 2011-08-18 | 2011-08-18 | 1d | 1d | 0d |
| 125 | 1.14.1.2.13 | PRELIMINARY: System Design Document (SDD) |  | 1d | 2011-09-27 | 2011-09-27 | 38, 104 | 2011-08-22 | 2011-08-22 | 1d | 0d |  |
| 126 | 1.14.1.2.14 | PRELIMINARY: Interface Control Document (ICD) |  | 1d | 2011-09-27 | 2011-09-27 | 125SS | 2011-08-22 | 2011-08-22 | 1d | 0d |  |
| 127 | 1.14.1.2.15 | PRELIMINARY: Database Design Document |  | 1d | 2011-09-27 | 2011-09-27 | 125SS | 2011-08-22 | 2011-08-22 | 1d | 0d |  |
| 128 | 1.14.1.2.16 | PRELIMINARY: Data Use Agreement |  | 1d | 2011-09-27 | 2011-09-27 | 125SS | 2011-08-22 | 2011-08-22 | 1d | 0d |  |
| 129 | 1.14.1.2.17 | PRELIMINARY: Data Conversion Plan |  | 1d | 2011-09-27 | 2011-09-27 | 125SS | 2011-08-22 | 2011-08-22 | 1d | 0d |  |
| 130 | 1.14.1.2.18 | PRELIMINARY: Physical Database/Model |  | 1d | 2011-09-27 | 2011-09-27 | 125SS | 2011-08-22 | 2011-08-22 | 1d | 0d |  |
| 131 | 1.14.1.2.19 | PRELIMINARY: Computer Match Agreement /Interagency Agreement (CMA/IA) |  | 1d | 2011-09-27 | 2011-09-27 | 125SS | 2011-08-22 | 2011-08-22 | 1d | 0d |  |
| 132 | 1.14.1.3 | Schedule and Prepare for Preliminary Design Review (PDR) |  | 1d | 2011-09-28 | 2011-09-28 | 112, 109 | 2011-08-23 | 2011-08-23 | 1d | 0d |  |
| 133 | 1.14.1.4 | MILESTONE: Preliminary Design Review (PDR) | milestone | 0d | 2011-09-28 | 2011-09-28 | 132 | 2011-08-23 | 2011-08-23 | 0d | 14d |  |
| 134 | 1.14.2 | MILESTONE: Preliminary Design Completed | milestone | 0d | 2011-09-28 | 2011-09-28 | 108 | 2011-08-23 | 2011-08-23 | 0d | 14d |  |

Notes:
- 124: Also see CMS Testing Framework Overview (http://www.cms.gov/SystemLifecycleFramework/downloads/CMSTestingFrameworkOverview.pdf)
- 128: NOTE: The Data Use Agreement (DUA) templates can be found on CMS' internal Forms Locator website.

| ID | WBS | Task | Type | Duration | Start | Finish | Predecessors | Baseline start | Baseline finish | Baseline duration | Total slack | Free slack |
| --- | --- | --- | --- | --- | --- | --- | --- | --- | --- | --- | --- | --- |
| 135 | 1.14.3 | **Detailed Design** |  | 9d | 2011-09-20 | 2011-09-30 |  | 2011-08-19 | 2011-08-25 | 5d | 7d | 0d |
| 136 | 1.14.3.1 | **Detailed Design Phase Tasks** |  | 1d | 2011-09-29 | 2011-09-29 |  | 2011-08-24 | 2011-08-24 | 1d | 0d |  |
| 137 | 1.14.3.1.1 | Detailed Design Phase Task 1 |  | 1d | 2011-09-29 | 2011-09-29 | 132 | 2011-08-24 | 2011-08-24 | 1d | 0d |  |
| 138 | 1.14.3.1.2 | Detailed Design Phase Task n |  | 1d | 2011-09-29 | 2011-09-29 | 137SS | 2011-08-24 | 2011-08-24 | 1d | 0d |  |
| 139 | 1.14.3.2 | **Detailed Design Phase Artifacts** |  | 8d | 2011-09-20 | 2011-09-29 |  | 2011-08-19 | 2011-08-24 | 4d | 0d |  |
| 140 | 1.14.3.2.1 | FINAL: Release Plan |  | 1d | 2011-09-29 | 2011-09-29 | 132 | 2011-08-24 | 2011-08-24 | 1d | 0d |  |
| 141 | 1.14.3.2.2 | FINAL: System of Records Notice (SORN) |  | 1d | 2011-09-26 | 2011-09-26 | 103 | 2011-08-19 | 2011-08-19 | 1d | 3d |  |
| 142 | 1.14.3.2.3 | FINAL: Physical Database/Model |  | 1d | 2011-09-28 | 2011-09-28 | 130 | 2011-08-23 | 2011-08-23 | 1d | 1d |  |
| 143 | 1.14.3.2.4 | FINAL: Computer Match Agreement /Interagency Agreement (CMA/IA) |  | 1d | 2011-09-28 | 2011-09-28 | 131 | 2011-08-22 | 2011-08-22 | 1d | 1d |  |
| 144 | 1.14.3.2.5 | BASELINE: System Design Document (SDD) |  | 1d | 2011-09-28 | 2011-09-28 | 125 | 2011-08-23 | 2011-08-23 | 1d | 1d |  |
| 145 | 1.14.3.2.6 | BASELINE: Interface Control Document (ICD) |  | 1d | 2011-09-28 | 2011-09-28 | 126 | 2011-08-23 | 2011-08-23 | 1d | 1d |  |
| 146 | 1.14.3.2.7 | INTERIM: Project Schedule |  | 1d | 2011-09-26 | 2011-09-26 | 113 | 2011-08-16 | 2011-08-16 | 1d | 3d | 0d |
| 147 | 1.14.3.2.8 | INTERIM: Section 508 Product Assessment Package |  | 1d | 2011-09-20 | 2011-09-20 | 114 | 2011-08-09 | 2011-08-09 | 1d | 7d | 0d |
| 148 | 1.14.3.2.9 | INTERIM: Information Security Risk Assessment (ISRA) |  | 1d | 2011-09-20 | 2011-09-20 | 115 | 2011-08-10 | 2011-08-10 | 1d | 7d | 0d |
| 149 | 1.14.3.2.10 | INTERIM: System Security Plan (SSP) |  | 1d | 2011-09-20 | 2011-09-20 | 116 | 2011-08-11 | 2011-08-11 | 1d | 7d | 0d |
| 150 | 1.14.3.2.11 | INTERIM: Privacy Impact Assessment (PIA) |  | 1d | 2011-09-20 | 2011-09-20 | 117 | 2011-08-15 | 2011-08-15 | 1d | 7d | 0d |
| 151 | 1.14.3.2.12 | INTERIM: Contingency Plan |  | 1d | 2011-09-20 | 2011-09-20 | 118 | 2011-08-18 | 2011-08-18 | 1d | 7d | 0d |
| 152 | 1.14.3.2.13 | INTERIM: Risk Register |  | 1d | 2011-09-26 | 2011-09-26 | 119 | 2011-08-16 | 2011-08-16 | 1d | 3d | 0d |
| 153 | 1.14.3.2.14 | INTERIM: Issues List |  | 1d | 2011-09-26 | 2011-09-26 | 120 | 2011-08-16 | 2011-08-16 | 1d | 3d | 0d |
| 154 | 1.14.3.2.15 | INTERIM: Action Items |  | 1d | 2011-09-26 | 2011-09-26 | 121 | 2011-08-16 | 2011-08-16 | 1d | 3d | 0d |
| 155 | 1.14.3.2.16 | INTERIM: Decision Log |  | 1d | 2011-09-26 | 2011-09-26 | 122 | 2011-08-16 | 2011-08-16 | 1d | 3d | 0d |
| 156 | 1.14.3.2.17 | INTERIM: Lessons Learned |  | 1d | 2011-09-26 | 2011-09-26 | 123 | 2011-08-16 | 2011-08-16 | 1d | 3d | 0d |
| 157 | 1.14.3.2.18 | INTERIM: Test Plan |  | 1d | 2011-09-27 | 2011-09-27 | 124 | 2011-08-18 | 2011-08-18 | 1d | 2d |  |
| 158 | 1.14.3.2.19 | INTERIM: Database Design Document |  | 1d | 2011-09-28 | 2011-09-28 | 127 | 2011-08-22 | 2011-08-22 | 1d | 1d |  |
| 159 | 1.14.3.2.20 | INTERIM: Data Use Agreement |  | 1d | 2011-09-28 | 2011-09-28 | 128 | 2011-08-22 | 2011-08-22 | 1d | 1d | 0d |
| 160 | 1.14.3.2.21 | INTERIM: Data Conversion Plan |  | 1d | 2011-09-28 | 2011-09-28 | 129 | 2011-08-22 | 2011-08-22 | 1d | 1d |  |
| 161 | 1.14.3.2.22 | PRELIMINARY: Test Case Specification |  | 1d | 2011-09-29 | 2011-09-29 | 132 | 2011-08-24 | 2011-08-24 | 1d | 0d |  |
| 162 | 1.14.3.2.23 | PRELIMINARY: Implementation Plan |  | 1d | 2011-09-29 | 2011-09-29 | 132 | 2011-08-24 | 2011-08-24 | 1d | 0d |  |
| 163 | 1.14.3.2.24 | PRELIMINARY: User Manual |  | 1d | 2011-09-29 | 2011-09-29 | 132 | 2011-08-24 | 2011-08-24 | 1d | 0d |  |
| 164 | 1.14.3.2.25 | PRELIMINARY: Operations & Maintenance Manual (OMM) |  | 1d | 2011-09-29 | 2011-09-29 | 132 | 2011-08-24 | 2011-08-24 | 1d | 0d |  |
| 165 | 1.14.3.3 | Schedule and Prepare for Detailed Design Review (DDR) |  | 1d | 2011-09-30 | 2011-09-30 | 139, 136 | 2011-08-25 | 2011-08-25 | 1d | 0d |  |
| 166 | 1.14.3.4 | MILESTONE: Detailed Design Review (DDR) | milestone | 0d | 2011-09-30 | 2011-09-30 | 165 | 2011-08-25 | 2011-08-25 | 0d | 12d |  |
| 167 | 1.14.4 | MILESTONE: Detailed Design Completed | milestone | 0d | 2011-09-30 | 2011-09-30 | 135 | 2011-08-25 | 2011-08-25 | 0d | 12d |  |
| 168 | 1.15 | MILESTONE: Design Phase Complete (PROJECT NAME) | milestone | 0d | 2011-09-30 | 2011-09-30 | 107 | 2011-08-25 | 2011-08-25 | 0d | 12d |  |

Notes:
- 157: Also see CMS Testing Framework Overview (http://www.cms.gov/SystemLifecycleFramework/downloads/CMSTestingFrameworkOverview.pdf)
- 159: NOTE: The Data Use Agreement (DUA) templates can be found on CMS' internal Forms Locator website.

| ID | WBS | Task | Type | Duration | Start | Finish | Predecessors | Baseline start | Baseline finish | Baseline duration | Total slack | Free slack |
| --- | --- | --- | --- | --- | --- | --- | --- | --- | --- | --- | --- | --- |
| 169 | 1.16 | **Development Phase (PROJECT NAME)** |  | 10d | 2011-09-21 | 2011-10-04 |  | 2011-08-19 | 2011-08-29 | 7d | 7d | 0d |
| 170 | 1.16.1 | **Development Phase Tasks** |  | 1d | 2011-10-03 | 2011-10-03 |  | 2011-08-26 | 2011-08-26 | 1d | 0d |  |
| 171 | 1.16.1.1 | Development Phase Task 1 |  | 1d | 2011-10-03 | 2011-10-03 | 165 | 2011-08-26 | 2011-08-26 | 1d | 0d |  |
| 172 | 1.16.1.2 | Development Phase Task n |  | 1d | 2011-10-03 | 2011-10-03 | 171SS | 2011-08-26 | 2011-08-26 | 1d | 0d |  |
| 173 | 1.16.2 | **Development Phase Artifacts** |  | 9d | 2011-09-21 | 2011-10-03 |  | 2011-08-19 | 2011-08-26 | 6d | 0d |  |
| 174 | 1.16.2.1 | FINAL: Database Design Document |  | 1d | 2011-09-28 | 2011-09-28 | 127 | 2011-08-23 | 2011-08-23 | 1d | 3d |  |
| 175 | 1.16.2.2 | FINAL: Data Conversion Plan |  | 1d | 2011-09-28 | 2011-09-28 | 129 | 2011-08-23 | 2011-08-23 | 1d | 3d |  |
| 176 | 1.16.2.3 | FINAL: Test Case Specification |  | 1d | 2011-09-30 | 2011-09-30 | 161 | 2011-08-25 | 2011-08-25 | 1d | 1d | 0d |
| 177 | 1.16.2.4 | FINAL: Training Plan |  | 1d | 2011-10-03 | 2011-10-03 | 132, 165 | 2011-08-26 | 2011-08-26 | 1d | 0d |  |
| 178 | 1.16.2.5 | BASELINE: Business Product / Code |  | 1d | 2011-10-03 | 2011-10-03 | 165, 132 | 2011-08-26 | 2011-08-26 | 1d | 0d |  |
| 179 | 1.16.2.6 | BASELINE: Test Plan |  | 1d | 2011-10-03 | 2011-10-03 | 102, 165, 132 | 2011-08-26 | 2011-08-26 | 1d | 0d |  |
| 180 | 1.16.2.7 | INTERIM: Project Schedule |  | 1d | 2011-09-27 | 2011-09-27 | 146 | 2011-08-16 | 2011-08-16 | 1d | 4d | 0d |
| 181 | 1.16.2.8 | INTERIM: Section 508 Product Assessment Package |  | 1d | 2011-09-21 | 2011-09-21 | 147 | 2011-08-09 | 2011-08-09 | 1d | 8d | 0d |
| 182 | 1.16.2.9 | INTERIM: Information Security Risk Assessment (ISRA) |  | 1d | 2011-09-21 | 2011-09-21 | 148 | 2011-08-10 | 2011-08-10 | 1d | 7d | 0d |
| 183 | 1.16.2.10 | INTERIM: System Security Plan (SSP) |  | 1d | 2011-09-21 | 2011-09-21 | 149 | 2011-08-11 | 2011-08-11 | 1d | 7d | 0d |
| 184 | 1.16.2.11 | INTERIM: Privacy Impact Assessment (PIA) |  | 1d | 2011-09-21 | 2011-09-21 | 150 | 2011-08-15 | 2011-08-15 | 1d | 7d | 0d |
| 185 | 1.16.2.12 | INTERIM: Contingency Plan |  | 1d | 2011-09-21 | 2011-09-21 | 151 | 2011-08-18 | 2011-08-18 | 1d | 7d | 0d |
| 186 | 1.16.2.13 | INTERIM: Risk Register |  | 1d | 2011-09-27 | 2011-09-27 | 152 | 2011-08-16 | 2011-08-16 | 1d | 4d | 0d |
| 187 | 1.16.2.14 | INTERIM: Issues List |  | 1d | 2011-09-27 | 2011-09-27 | 153 | 2011-08-16 | 2011-08-16 | 1d | 4d | 0d |
| 188 | 1.16.2.15 | INTERIM: Action Items |  | 1d | 2011-09-27 | 2011-09-27 | 154 | 2011-08-16 | 2011-08-16 | 1d | 4d | 0d |
| 189 | 1.16.2.16 | INTERIM: Decision Log |  | 1d | 2011-09-27 | 2011-09-27 | 155 | 2011-08-16 | 2011-08-16 | 1d | 4d | 0d |
| 190 | 1.16.2.17 | INTERIM: Lessons Learned |  | 1d | 2011-09-27 | 2011-09-27 | 156 | 2011-08-16 | 2011-08-16 | 1d | 4d | 0d |
| 191 | 1.16.2.18 | INTERIM: Data Use Agreement |  | 1d | 2011-09-29 | 2011-09-29 | 159 | 2011-08-22 | 2011-08-22 | 1d | 1d | 0d |
| 192 | 1.16.2.19 | INTERIM: Implementation Plan |  | 1d | 2011-09-30 | 2011-09-30 | 162 | 2011-08-24 | 2011-08-24 | 1d | 1d | 0d |
| 193 | 1.16.2.20 | INTERIM: User Manual |  | 1d | 2011-09-30 | 2011-09-30 | 163 | 2011-08-24 | 2011-08-24 | 1d | 1d | 0d |
| 194 | 1.16.2.21 | INTERIM: Operations & Maintenance Manual (OMM) |  | 1d | 2011-09-30 | 2011-09-30 | 164 | 2011-08-24 | 2011-08-24 | 1d | 1d | 0d |
| 195 | 1.16.2.22 | PRELIMINARY: Version Description Document (VDD) |  | 1d | 2011-10-03 | 2011-10-03 | 132, 165 | 2011-08-26 | 2011-08-26 | 1d | 0d |  |
| 196 | 1.16.3 | Schedule and Prepare for Environment Readiness Review 1 (VRR) |  | 1d | 2011-10-04 | 2011-10-04 | 173, 170 | 2011-08-29 | 2011-08-29 | 1d | 0d |  |
| 197 | 1.16.4 | MILESTONE: Environment Readiness Review 1 (Validation) | milestone | 0d | 2011-10-04 | 2011-10-04 | 196 | 2011-08-29 | 2011-08-29 | 0d | 10d |  |
| 198 | 1.17 | MILESTONE: Development Phase Complete (PROJECT NAME) | milestone | 0d | 2011-10-04 | 2011-10-04 | 169 | 2011-08-29 | 2011-08-29 | 0d | 10d |  |

Notes:
- 179: Also see CMS Testing Framework Overview (http://www.cms.gov/SystemLifecycleFramework/downloads/CMSTestingFrameworkOverview.pdf)
- 191: NOTE: The Data Use Agreement (DUA) templates can be found on CMS' internal Forms Locator website.

| ID | WBS | Task | Type | Duration | Start | Finish | Predecessors | Baseline start | Baseline finish | Baseline duration | Total slack | Free slack |
| --- | --- | --- | --- | --- | --- | --- | --- | --- | --- | --- | --- | --- |
| 199 | 1.18 | **Test Phase (PROJECT NAME)** |  | 11d | 2011-09-22 | 2011-10-06 |  | 2011-08-11 | 2011-08-31 | 15d | 7d | 0d |
| 200 | 1.18.1 | **Test Phase Tasks** |  | 1d | 2011-10-05 | 2011-10-05 |  | 2011-08-30 | 2011-08-30 | 1d | 0d |  |
| 201 | 1.18.1.1 | Test Phase Task 1 |  | 1d | 2011-10-05 | 2011-10-05 | 196, 132 | 2011-08-30 | 2011-08-30 | 1d | 0d |  |
| 202 | 1.18.1.2 | Test Phase Task n |  | 1d | 2011-10-05 | 2011-10-05 | 201SS | 2011-08-30 | 2011-08-30 | 1d | 0d |  |
| 203 | 1.18.2 | **Test Phase Artifacts** |  | 9d | 2011-09-22 | 2011-10-04 |  | 2011-08-11 | 2011-08-29 | 13d | 1d |  |
| 204 | 1.18.2.1 | BASELINE: Version Description Document (VDD) |  | 1d | 2011-10-04 | 2011-10-04 | 195 | 2011-08-29 | 2011-08-29 | 1d | 1d |  |
| 205 | 1.18.2.2 | INTERIM: Project Schedule |  | 1d | 2011-09-28 | 2011-09-28 | 146, 180 | 2011-08-16 | 2011-08-16 | 1d | 5d | 0d |
| 206 | 1.18.2.3 | INTERIM: Section 508 Product Assessment Package |  | 1d | 2011-09-22 | 2011-09-22 | 147, 181 | 2011-08-09 | 2011-08-09 | 1d | 9d | 0d |
| 207 | 1.18.2.4 | INTERIM: Information Security Risk Assessment (ISRA) |  | 1d | 2011-09-22 | 2011-09-22 | 148, 182 | 2011-08-10 | 2011-08-10 | 1d | 7d | 0d |
| 208 | 1.18.2.5 | INTERIM: System Security Plan (SSP) |  | 1d | 2011-09-22 | 2011-09-22 | 149, 183 | 2011-08-11 | 2011-08-11 | 1d | 7d | 0d |
| 209 | 1.18.2.6 | INTERIM: Privacy Impact Assessment (PIA) |  | 1d | 2011-09-22 | 2011-09-22 | 150, 184 | 2011-08-15 | 2011-08-15 | 1d | 7d | 0d |
| 210 | 1.18.2.7 | INTERIM: Contingency Plan |  | 1d | 2011-09-22 | 2011-09-22 | 151, 185 | 2011-08-18 | 2011-08-18 | 1d | 7d | 0d |
| 211 | 1.18.2.8 | INTERIM: Risk Register |  | 1d | 2011-09-28 | 2011-09-28 | 152, 186 | 2011-08-16 | 2011-08-16 | 1d | 5d | 0d |
| 212 | 1.18.2.9 | INTERIM: Issues List |  | 1d | 2011-09-28 | 2011-09-28 | 153, 187 | 2011-08-16 | 2011-08-16 | 1d | 5d | 0d |
| 213 | 1.18.2.10 | INTERIM: Action Items |  | 1d | 2011-09-28 | 2011-09-28 | 154, 188 | 2011-08-16 | 2011-08-16 | 1d | 5d | 0d |
| 214 | 1.18.2.11 | INTERIM: Decision Log |  | 1d | 2011-09-28 | 2011-09-28 | 155, 189 | 2011-08-16 | 2011-08-16 | 1d | 5d | 0d |
| 215 | 1.18.2.12 | INTERIM: Lessons Learned |  | 1d | 2011-09-28 | 2011-09-28 | 156, 190 | 2011-08-16 | 2011-08-16 | 1d | 5d | 0d |
| 216 | 1.18.2.13 | INTERIM: Data Use Agreement |  | 1d | 2011-09-30 | 2011-09-30 | 157, 191 | 2011-08-22 | 2011-08-22 | 1d | 1d | 0d |
| 217 | 1.18.2.14 | INTERIM: Implementation Plan |  | 1d | 2011-10-03 | 2011-10-03 | 158, 192 | 2011-08-24 | 2011-08-24 | 1d | 2d |  |
| 218 | 1.18.2.15 | INTERIM: User Manual |  | 1d | 2011-10-03 | 2011-10-03 | 159, 193 | 2011-08-24 | 2011-08-24 | 1d | 2d |  |
| 219 | 1.18.2.16 | INTERIM: Operations & Maintenance Manual (OMM) |  | 1d | 2011-10-03 | 2011-10-03 | 160, 194 | 2011-08-24 | 2011-08-24 | 1d | 2d |  |
| 220 | 1.18.2.17 | PRELIMINARY: Contingency Plan Test |  | 1d | 2011-09-23 | 2011-09-23 | 210 | 2011-09-01 | 2011-09-01 | 1d | 7d | 0d |
| 221 | 1.18.2.18 | PRELIMINARY: Security Assessment |  | 1d | 2011-09-23 | 2011-09-23 | 207, 208, 209 |  |  |  | 7d | 0d |
| 222 | 1.18.2.19 | PRELIMINARY: Authorization Package |  | 1d | 2011-09-26 | 2011-09-26 | 207, 208, 209, 210, 220, 221 | 2011-09-02 | 2011-09-02 | 1d | 7d |  |
| 223 | 1.18.2.20 | PRELIMINARY: Test Summary Report |  | 1d | 2011-10-03 | 2011-10-03 | 176 | 2011-08-26 | 2011-08-26 | 1d | 2d | 0d |
| 224 | 1.18.2.21 | PRELIMINARY: Training Artifacts |  | 1d | 2011-10-04 | 2011-10-04 | 177 | 2011-08-29 | 2011-08-29 | 1d | 1d | 0d |
| 225 | 1.18.3 | Schedule and Prepare for Environment Readiness Review 2 (IRR) |  | 1d | 2011-10-06 | 2011-10-06 | 203, 200 | 2011-08-31 | 2011-08-31 | 1d | 0d |  |
| 226 | 1.18.4 | MILESTONE: Environment Readiness Review 2 (Implementation) | milestone | 0d | 2011-10-06 | 2011-10-06 | 225 | 2011-08-31 | 2011-08-31 | 0d | 8d |  |
| 227 | 1.19 | MILESTONE: Test Phase Complete (PROJECT NAME) | milestone | 0d | 2011-10-06 | 2011-10-06 | 199 | 2011-08-31 | 2011-08-31 | 0d | 8d |  |

Notes:
- 216: NOTE: The Data Use Agreement (DUA) templates can be found on CMS' internal Forms Locator website.

| ID | WBS | Task | Type | Duration | Start | Finish | Predecessors | Baseline start | Baseline finish | Baseline duration | Total slack | Free slack |
| --- | --- | --- | --- | --- | --- | --- | --- | --- | --- | --- | --- | --- |
| 228 | 1.20 | **Implementation Phase (PROJECT NAME)** |  | 15d | 2011-09-22 | 2011-10-13 |  | 2011-08-10 | 2011-09-06 | 20d | 4d | 0d |
| 229 | 1.20.1 | **Production Readiness** |  | 12d | 2011-09-23 | 2011-10-11 |  | 2011-08-10 | 2011-09-02 | 18d | 6d | 0d |
| 230 | 1.20.1.1 | **Implementation Phase PRR Tasks** |  | 1d | 2011-10-07 | 2011-10-07 |  | 2011-09-01 | 2011-09-01 | 1d | 0d |  |
| 231 | 1.20.1.1.1 | Implementation Phase PRR Task 1 |  | 1d | 2011-10-07 | 2011-10-07 | 225 | 2011-09-01 | 2011-09-01 | 1d | 0d |  |
| 232 | 1.20.1.1.2 | Implementation Phase PRR Task n |  | 1d | 2011-10-07 | 2011-10-07 | 231SS | 2011-09-01 | 2011-09-01 | 1d | 0d |  |
| 233 | 1.20.1.2 | **Implementation Phase PRR Artifacts** |  | 10d | 2011-09-23 | 2011-10-06 |  | 2011-08-10 | 2011-09-01 | 17d | 1d |  |
| 234 | 1.20.1.2.1 | FINAL: Information Security Risk Assessment (ISRA) |  | 1d | 2011-09-23 | 2011-09-23 | 148, 207 | 2011-08-10 | 2011-08-10 | 1d | 8d | 0d |
| 235 | 1.20.1.2.2 | FINAL: System Security Plan (SSP) |  | 1d | 2011-09-23 | 2011-09-23 | 149, 208 | 2011-08-11 | 2011-08-11 | 1d | 8d | 0d |
| 236 | 1.20.1.2.3 | FINAL: Privacy Impact Assessment (PIA) |  | 1d | 2011-09-23 | 2011-09-23 | 150, 209 | 2011-08-15 | 2011-08-15 | 1d | 8d | 0d |
| 237 | 1.20.1.2.4 | FINAL: Contingency Plan Test |  | 1d | 2011-10-03 | 2011-10-03 | 220, 165 | 2011-09-01 | 2011-09-01 | 1d | 3d | 0d |
| 238 | 1.20.1.2.5 | FINAL: Security Assessment |  | 1d | 2011-09-26 | 2011-09-26 | 234, 235, 236 |  |  |  | 8d | 0d |
| 239 | 1.20.1.2.6 | FINAL: Authorization Package |  | 1d | 2011-10-04 | 2011-10-04 | 237, 234, 235, 236, 238, 242 | 2011-09-02 | 2011-09-02 | 1d | 3d | 0d |
| 240 | 1.20.1.2.7 | INTERIM: Project Schedule |  | 1d | 2011-09-29 | 2011-09-29 | 146, 205 | 2011-08-16 | 2011-08-16 | 1d | 6d | 0d |
| 241 | 1.20.1.2.8 | INTERIM: Section 508 Product Assessment Package |  | 1d | 2011-09-23 | 2011-09-23 | 147, 206 | 2011-08-10 | 2011-08-10 | 1d | 10d | 0d |
| 242 | 1.20.1.2.9 | INTERIM: Contingency Plan |  | 1d | 2011-09-23 | 2011-09-23 | 151, 210 | 2011-08-18 | 2011-08-18 | 1d | 9d | 0d |
| 243 | 1.20.1.2.10 | INTERIM: Risk Register |  | 1d | 2011-09-29 | 2011-09-29 | 152, 211 | 2011-08-16 | 2011-08-16 | 1d | 6d | 0d |
| 244 | 1.20.1.2.11 | INTERIM: Issues List |  | 1d | 2011-09-29 | 2011-09-29 | 153, 212 | 2011-08-16 | 2011-08-16 | 1d | 6d |  |
| 245 | 1.20.1.2.12 | INTERIM: Action Items |  | 1d | 2011-09-29 | 2011-09-29 | 154, 213 | 2011-08-16 | 2011-08-16 | 1d | 6d |  |
| 246 | 1.20.1.2.13 | INTERIM: Decision Log |  | 1d | 2011-09-29 | 2011-09-29 | 155, 214 | 2011-08-16 | 2011-08-16 | 1d | 6d |  |
| 247 | 1.20.1.2.14 | INTERIM: Lessons Learned |  | 1d | 2011-09-29 | 2011-09-29 | 156, 215 | 2011-08-16 | 2011-08-16 | 1d | 6d |  |
| 248 | 1.20.1.2.15 | INTERIM: Data Use Agreement (DUA) |  | 1d | 2011-10-03 | 2011-10-03 | 216, 159 | 2011-08-23 | 2011-08-23 | 1d | 1d | 0d |
| 249 | 1.20.1.2.16 | INTERIM: Implementation Plan |  | 1d | 2011-10-04 | 2011-10-04 | 162, 248 | 2011-08-25 | 2011-08-25 | 1d | 1d | 0d |
| 250 | 1.20.1.2.17 | INTERIM: User Manual |  | 1d | 2011-10-05 | 2011-10-05 | 163, 249 | 2011-08-25 | 2011-08-25 | 1d | 1d | 0d |
| 251 | 1.20.1.2.18 | INTERIM: Operations & Maintenance Manual |  | 1d | 2011-10-06 | 2011-10-06 | 164, 250 | 2011-08-25 | 2011-08-25 | 1d | 1d | 0d |
| 252 | 1.20.1.2.19 | INTERIM: Test Summary Report |  | 1d | 2011-10-04 | 2011-10-04 | 223, 176 | 2011-08-26 | 2011-08-26 | 1d | 3d | 0d |
| 253 | 1.20.1.2.20 | INTERIM: Training Artifacts |  | 1d | 2011-10-05 | 2011-10-05 | 177, 224 | 2011-08-30 | 2011-08-30 | 1d | 2d | 1d |
| 254 | 1.20.1.3 | Schedule and Prepare for Environment Readiness Review 3 (PRR) |  | 1d | 2011-10-11 | 2011-10-11 | 230, 233 | 2011-09-02 | 2011-09-02 | 1d | 0d |  |
| 255 | 1.20.1.4 | MILESTONE: Environment Readiness Review 3 (Production) | milestone | 0d | 2011-10-11 | 2011-10-11 | 254 | 2011-09-02 | 2011-09-02 | 0d | 6d |  |
| 256 | 1.20.2 | MILESTONE: Production Readiness Completed | milestone | 0d | 2011-10-11 | 2011-10-11 | 229 | 2011-09-02 | 2011-09-02 | 0d | 6d |  |

Notes:
- 248: NOTE: The Data Use Agreement (DUA) templates can be found on CMS' internal Forms Locator website.

| ID | WBS | Task | Type | Duration | Start | Finish | Predecessors | Baseline start | Baseline finish | Baseline duration | Total slack | Free slack |
| --- | --- | --- | --- | --- | --- | --- | --- | --- | --- | --- | --- | --- |
| 257 | 1.20.3 | **Operational Readiness** |  | 15d | 2011-09-22 | 2011-10-13 |  | 2011-08-17 | 2011-09-06 | 15d | 4d | 0d |
| 258 | 1.20.3.1 | **Implementation Phase ORR Tasks** |  | 1d | 2011-10-07 | 2011-10-07 |  | 2011-09-02 | 2011-09-02 | 1d | 2d |  |
| 259 | 1.20.3.1.1 | Implementation Phase ORR Task 1 |  | 1d | 2011-10-07 | 2011-10-07 | 38, 225, 253 | 2011-09-02 | 2011-09-02 | 1d | 2d | 0d |
| 260 | 1.20.3.1.2 | Implementation Phase ORR Task n |  | 1d | 2011-10-07 | 2011-10-07 | 259SS | 2011-09-02 | 2011-09-02 | 1d | 2d |  |
| 261 | 1.20.3.2 | **Implementation Phase ORR Artifacts** |  | 14d | 2011-09-22 | 2011-10-12 |  | 2011-08-17 | 2011-09-05 | 14d | 0d |  |
| 262 | 1.20.3.2.1 | FINAL: Plan of Action & Milestones (POA&M) |  | 1d | 2011-10-12 | 2011-10-12 | 132, 254, 196, 225, 38 | 2011-09-05 | 2011-09-05 | 1d | 0d |  |
| 263 | 1.20.3.2.2 | FINAL: Project Schedule |  | 1d | 2011-09-30 | 2011-09-30 | 146, 205, 240 | 2011-08-16 | 2011-08-16 | 1d | 7d |  |
| 264 | 1.20.3.2.3 | FINAL: Risk Register |  | 1d | 2011-09-30 | 2011-09-30 | 152, 243 | 2011-08-16 | 2011-08-16 | 1d | 7d |  |
| 265 | 1.20.3.2.4 | FINAL: Issues List |  | 1d | 2011-09-22 | 2011-09-22 | 76 | 2011-08-17 | 2011-08-17 | 1d | 13d |  |
| 266 | 1.20.3.2.5 | FINAL: Action Items |  | 1d | 2011-09-22 | 2011-09-22 | 77 | 2011-08-17 | 2011-08-17 | 1d | 13d |  |
| 267 | 1.20.3.2.6 | FINAL: Decision Log |  | 1d | 2011-09-22 | 2011-09-22 | 78 | 2011-08-17 | 2011-08-17 | 1d | 13d |  |
| 268 | 1.20.3.2.7 | FINAL: Lessons Learned Log |  | 1d | 2011-09-22 | 2011-09-22 | 79 | 2011-08-17 | 2011-08-17 | 1d | 13d |  |
| 269 | 1.20.3.2.8 | FINAL: Section 508 Product Assessment Package |  | 1d | 2011-09-26 | 2011-09-26 | 147, 241 | 2011-08-10 | 2011-08-10 | 1d | 11d |  |
| 270 | 1.20.3.2.9 | FINAL: Data Use Agreement (DUA) |  | 1d | 2011-10-04 | 2011-10-04 | 159, 248 | 2011-08-23 | 2011-08-23 | 1d | 5d |  |
| 271 | 1.20.3.2.10 | FINAL: Implementation Plan |  | 1d | 2011-10-05 | 2011-10-05 | 249, 162 | 2011-08-25 | 2011-08-25 | 1d | 4d |  |
| 272 | 1.20.3.2.11 | FINAL: User Manual |  | 1d | 2011-10-06 | 2011-10-06 | 250, 163 | 2011-08-25 | 2011-08-25 | 1d | 3d |  |
| 273 | 1.20.3.2.12 | FINAL: Operations & Maintenance Manual |  | 1d | 2011-10-07 | 2011-10-07 | 164, 251 | 2011-08-25 | 2011-08-25 | 1d | 2d |  |
| 274 | 1.20.3.2.13 | FINAL: Test Summary Report |  | 1d | 2011-10-05 | 2011-10-05 | 176, 252 | 2011-08-26 | 2011-08-26 | 1d | 4d |  |
| 275 | 1.20.3.2.14 | FINAL: Training Artifacts |  | 1d | 2011-10-05 | 2011-10-05 | 224 | 2011-08-30 | 2011-08-30 | 1d | 4d |  |
| 276 | 1.20.3.2.15 | FINAL: CMS CIO-Issued Authorization to Operate (ATO) |  | 1d | 2011-10-05 | 2011-10-05 | 239 | 2011-09-05 | 2011-09-05 | 1d | 4d |  |
| 277 | 1.20.3.2.16 | INTERIM: Contingency Plan |  | 1d | 2011-09-26 | 2011-09-26 | 151, 242 | 2011-08-18 | 2011-08-18 | 1d | 11d | 0d |
| 278 | 1.20.3.3 | Schedule and Prepare for Operational Readiness Review (ORR) |  | 1d | 2011-10-13 | 2011-10-13 | 10, 179, 178, 261, 233, 237, 132, 145, 258 | 2011-09-06 | 2011-09-06 | 1d | 0d |  |
| 279 | 1.20.3.4 | MILESTONE: Operational Readiness Review | milestone | 0d | 2011-10-13 | 2011-10-13 | 278 | 2011-09-06 | 2011-09-06 | 0d | 4d |  |
| 280 | 1.20.4 | MILESTONE: Operational Readiness Completed | milestone | 0d | 2011-10-13 | 2011-10-13 | 257 | 2011-09-06 | 2011-09-06 | 0d | 4d |  |
| 281 | 1.21 | MILESTONE: Implementation Phase Complete (PROJECT NAME) | milestone | 0d | 2011-10-13 | 2011-10-13 | 228 | 2011-09-06 | 2011-09-06 | 0d | 4d |  |

Notes:
- 270: NOTE: The Data Use Agreement (DUA) templates can be found on CMS' internal Forms Locator website.

| ID | WBS | Task | Type | Duration | Start | Finish | Predecessors | Baseline start | Baseline finish | Baseline duration | Total slack | Free slack |
| --- | --- | --- | --- | --- | --- | --- | --- | --- | --- | --- | --- | --- |
| 282 | 1.22 | **Operations & Maintenance (O&M) Phase (PROJECT NAME)** |  | 15d | 2011-09-26 | 2011-10-17 |  | 2011-09-07 | 2011-09-08 | 2d | 2d | 0d |
| 283 | 1.22.1 | **O&M Phase Tasks** |  | 1d | 2011-10-14 | 2011-10-14 |  | 2011-09-07 | 2011-09-07 | 1d | 0d |  |
| 284 | 1.22.1.1 | Operations & Maintenance Phase Task 1 |  | 1d | 2011-10-14 | 2011-10-14 | 278 | 2011-09-07 | 2011-09-07 | 1d | 0d |  |
| 285 | 1.22.1.2 | Operations & Maintenance Phase Task n |  | 1d | 2011-10-14 | 2011-10-14 | 284SS | 2011-09-07 | 2011-09-07 | 1d | 0d |  |
| 286 | 1.22.2 | **O&M Phase Artifacts** |  | 14d | 2011-09-26 | 2011-10-14 |  | 2011-09-07 | 2011-09-07 | 1d | 3d |  |
| 287 | 1.22.2.1 | FINAL: Project Closeout Report |  | 1d | 2011-10-14 | 2011-10-14 | 290SS | 2011-09-07 | 2011-09-07 | 1d | 0d |  |
| 288 | 1.22.2.2 | FINAL: Contingency Plan |  | 1d | 2011-09-27 | 2011-09-27 | 277 | 2011-08-18 | 2011-08-18 | 1d | 15d |  |
| 289 | 1.22.2.3 | FINAL: Security Monitoring Reports |  | 1d | 2011-10-14 | 2011-10-14 | 290SS | 2011-09-07 | 2011-09-07 | 1d | 0d |  |
| 290 | 1.22.2.4 | FINAL: System Disposition Plan |  | 1d | 2011-10-14 | 2011-10-14 | 278 | 2011-09-07 | 2011-09-07 | 1d | 0d |  |
| 291 | 1.22.2.5 | FINAL: Post Implementation Report |  | 1d | 2011-10-14 | 2011-10-14 | 290SS | 2011-09-07 | 2011-09-07 | 1d | 0d |  |
| 292 | 1.22.2.6 | FINAL: Annual Operational Analysis Report |  | 1d | 2011-10-14 | 2011-10-14 | 290SS | 2011-09-07 | 2011-09-07 | 1d | 0d |  |
| 293 | 1.22.2.7 | UPDATE: Information Security Risk Assessment (ISRA) |  | 1d | 2011-09-26 | 2011-09-26 | 234 | 2011-09-07 | 2011-09-07 | 1d | 13d |  |
| 294 | 1.22.2.8 | UPDATE: System Security Plan (SSP) |  | 1d | 2011-09-26 | 2011-09-26 | 235 | 2011-09-07 | 2011-09-07 | 1d | 16d |  |
| 295 | 1.22.2.9 | UPDATE: Privacy Impact Assessment (PIA) |  | 1d | 2011-09-26 | 2011-09-26 | 236 | 2011-08-15 | 2011-08-15 | 1d | 16d |  |
| 296 | 1.22.2.10 | UPDATE: Contingency Plan Test |  | 1d | 2011-10-04 | 2011-10-04 | 237 | 2011-09-07 | 2011-09-07 | 1d | 7d |  |
| 297 | 1.22.2.11 | UPDATE: Security Assessment |  | 1d | 2011-09-27 | 2011-09-27 | 238 |  |  |  | 15d |  |
| 298 | 1.22.2.12 | UPDATE: Authorization Package |  | 1d | 2011-10-05 | 2011-10-05 | 239 | 2011-09-02 | 2011-09-02 | 1d | 9d |  |
| 299 | 1.22.3 | Schedule and Prepare for Post Implementation Review (PIR) |  | 1d | 2011-10-17 | 2011-10-17 | 278, 287, 4, 291 | 2011-09-08 | 2011-09-08 | 1d | 0d |  |
| 300 | 1.22.4 | Schedule and Prepare for Annual Operational Assessment (AOA) |  | 1d | 2011-10-17 | 2011-10-17 | 293, 296, 292, 283, 289, 278 | 2011-09-08 | 2011-09-08 | 1d | 0d |  |
| 301 | 1.22.5 | MILESTONE: Post Implementation Review / Annual Operational Assessment | milestone | 0d | 2011-10-17 | 2011-10-17 | 300, 299 | 2011-09-08 | 2011-09-08 | 0d | 2d |  |
| 302 | 1.23 | MILESTONE: Operations & Maintenance (O & M) Phase Complete (PROJECT NAME) | milestone | 0d | 2011-10-17 | 2011-10-17 | 282 | 2011-09-08 | 2011-09-08 | 0d | 2d |  |
| 303 | 1.24 | **Disposition Phase (PROJECT NAME)** |  | 2d | 2011-10-18 | 2011-10-19 |  | 2011-09-09 | 2011-09-12 | 2d | 0d |  |
| 304 | 1.24.1 | **Disposition Phase Tasks** |  | 1d | 2011-10-18 | 2011-10-18 |  | 2011-09-09 | 2011-09-09 | 1d | 0d |  |
| 305 | 1.24.1.1 | Disposition Phase Task 1 |  | 1d | 2011-10-18 | 2011-10-18 | 300 | 2011-09-09 | 2011-09-09 | 1d | 0d |  |
| 306 | 1.24.1.2 | Disposition Phase Task 2 |  | 1d | 2011-10-18 | 2011-10-18 | 305SS | 2011-09-09 | 2011-09-09 | 1d | 0d |  |

| ID | WBS | Task | Type | Duration | Start | Finish | Predecessors | Baseline start | Baseline finish | Baseline duration | Total slack |
| --- | --- | --- | --- | --- | --- | --- | --- | --- | --- | --- | --- |
| 307 | 1.24.2 | **Disposition Phase Artifacts** |  | 1d | 2011-10-18 | 2011-10-18 |  | 2011-09-09 | 2011-09-09 | 1d | 0d |
| 308 | 1.24.2.1 | FINAL: Disposition Closeout Certificate |  | 1d | 2011-10-18 | 2011-10-18 | 278, 290, 299, 300 | 2011-09-09 | 2011-09-09 | 1d | 0d |
| 309 | 1.24.3 | Schedule and Prepare for Disposition Review (DR) |  | 1d | 2011-10-19 | 2011-10-19 | 306, 305, 308 | 2011-09-12 | 2011-09-12 | 1d | 0d |
| 310 | 1.24.4 | MILESTONE: Disposition Review | milestone | 0d | 2011-10-19 | 2011-10-19 | 309 | 2011-09-12 | 2011-09-12 | 0d | 0d |
| 311 | 1.25 | MILESTONE: Disposition Phase Complete (PROJECT NAME) | milestone | 0d | 2011-10-19 | 2011-10-19 | 303 | 2011-09-12 | 2011-09-12 | 0d | 0d |

Notes:
- 308: There is currently no such document template.
